# Schedule

Schedule from MS Project, 2009-04-01 to 2012-08-01.
MBARI

## Calendars

- Standard: Mon-Fri 08:00-12:00, 13:00-17:00; Sat-Sun off.

## Schedule

| ID | WBS | Task | Duration | Start | Finish | Predecessors | Total slack | Free slack | Constraint |
| --- | --- | --- | --- | --- | --- | --- | --- | --- | --- |
| 3 | 1 | Electrical Gen. at-sea test | 1d? | 2011-11-11 | 2011-11-11 |  | 188d |  | finish no earlier than 2011-11-11 |
| 9 | 2 | Power Converter Design, build and test | 197d? | 2011-06-01 | 2012-03-01 |  | 109d |  | start no earlier than 2011-06-01 |
| 14 | 3 | Control Enhancements | 153d? | 2012-01-02 | 2012-08-01 |  | 0d |  | start no earlier than 2012-01-02 |
| 18 | 4 | Dock Stabilization Tests | 176d? | 2011-06-01 | 2012-02-01 |  | 130d |  | start no earlier than 2011-06-01 |
| 22 | 5 | AUV Homing Tests | 140d? | 2011-05-02 | 2011-11-11 |  | 188d |  | start no earlier than 2011-05-02 |
| 27 | 6 | AUV Dock Design and Fabrication | 303d? | 2011-01-03 | 2012-02-29 |  | 110d |  | start no earlier than 2011-01-03 |
| 28 | 7 | Concept Development | 108d? | 2011-01-03 | 2011-06-01 |  | 111d | 0d | finish no earlier than 2011-06-01 |
| 29 | 8 | Concept Design Review | 1d? | 2011-06-02 | 2011-06-02 | 28 | 111d | 0d |  |
| 30 | 9 | Design work | 92d? | 2011-06-03 | 2011-10-10 | 29 | 111d | 0d | start no earlier than 2011-06-03 |
| 31 | 10 | Prelimiminary Design Review | 1d? | 2011-10-11 | 2011-10-11 | 30 | 111d | 0d | start no earlier than 2011-10-11 |
| 32 | 11 | Detailed Design Work | 38d? | 2011-10-12 | 2011-12-02 | 31 | 111d | 0d | start no earlier than 2011-10-12 |
| 33 | 12 | Critical Design Review | 1d? | 2011-12-05 | 2011-12-05 | 32 | 111d | 1d |  |
| 34 | 13 | Dock Fabrication | 40d? | 2011-12-07 | 2012-01-31 | 33 | 110d | 0d | finish no earlier than 2012-01-31 |
| 35 | 14 | Lab Integration and Test | 21d? | 2012-02-01 | 2012-02-29 | 34 | 110d |  | start no earlier than 2012-02-01 |
| 38 | 15 | AUV Dock Test to Stationary Mooring | 1d? | 2009-04-01 | 2009-04-01 |  | 870d |  |  |
| 42 | 16 | AUV Dock test to wave-energy buoy | 1d? | 2009-04-01 | 2009-04-01 |  | 870d |  |  |
| 45 | 17 | Two-Week Demonstration Deployment | 1d? | 2009-04-01 | 2009-04-01 |  | 870d |  |  |
| 49 | 18 | Final Report Writing | 1d? | 2009-04-01 | 2009-04-01 |  | 870d |  |  |
